# LhARA

Schedule from MS Project XML, 2019-12-19 to 2029-11-13, costs in £.

## Calendars

- Standard: Mon-Fri 08:00-12:00, 13:00-17:00; Sat-Sun off.

## Resources

| Resource | Rate |
| --- | --- |
| Rbio_PDRA_1 |  |
| GL material | 250000 |
| GL_PDRA_1 |  |
| GL_PDRA_2 |  |
| GL_PG_1 |  |
| GL_PG_2 |  |
| LAS_PDRA_1 |  |
| Eng_1 |  |
| Eng_2 |  |
| FD_PDRA_1 |  |
| S2_PDRA_1 |  |
| RF_PDRA_1 |  |
| RF_PG_1 |  |
| RF_ENG_1 |  |
| MAG_ENG_1 |  |
| MAG_PDRA_1 |  |
| MAG_PG_1 |  |
| S2_PDRA_2 |  |
| S2_PG_1 |  |
| S2_PG_2 |  |
| INST_PDRA_1 |  |
| LAS_PG_1 |  |
| S1_PG_1 |  |
| DAQ_PG_1 |  |
| CNM_PDRA_1 |  |
| COMP_TECH_1 |  |
| FD_PG_1 |  |
| Rbio_PG_1 |  |
| Rbio_PDRA_2 |  |
| FFA_PG_1 |  |
| INST_PG_2 |  |
| INST_PG_1 |  |
| COMP material | 200000 |

## Schedule

| ID | WBS | Task | Type | Duration | Start | Finish | Predecessors | Total slack | Free slack | Constraint | Resources | Work | Cost |
| --- | --- | --- | --- | --- | --- | --- | --- | --- | --- | --- | --- | --- | --- |
| 1 | 1 | LhARA Stage 1 construction |  | 480d | 2023-06-07 | 2025-04-08 | 53 | 0d |  |  |  | 8h |  |
| 2 | 2 | LhARA Stage 2 construction |  | 1200d | 2024-09-25 | 2029-05-01 | 15 | 140d |  | start no earlier than 2019-12-19 |  | 9600h |  |
| 3 | 3 | **Radiobiology** |  | 2584d | 2019-12-19 | 2029-11-13 |  | 0d |  | start no earlier than 2019-12-19 |  | 20160h |  |
| 4 | 3.1 | Radiobiology at partner facilities |  | 1320d | 2019-12-19 | 2025-01-08 |  | 1264d |  | start no earlier than 2019-12-19 | Rbio_PDRA_1 [50%]; Rbio_PG_1 [50%] | 10560h |  |
| 5 | 3.2 | Radiobiology at LhARA |  | 1200d | 2025-04-09 | 2029-11-13 | 1 | 0d |  | start no earlier than 2019-12-19 | Rbio_PDRA_1 | 9600h |  |
| 6 | 4 | **System/near clinical aspects** |  | 2583d | 2019-12-20 | 2029-11-13 |  | 0d |  | start no earlier than 2019-12-19 | Rbio_PDRA_2 | 20680h |  |
| 7 | 4.1 | Pre-LhARA: in collaboration with RFI SnL theme and other partners |  | 1320d | 2019-12-20 | 2025-01-09 |  | 1263d |  | start no earlier than 2019-12-20 |  | 8h |  |
| 8 | 4.2 | LhARA: in collaboration with RFI SnL theme and other partners |  | 1200d | 2025-04-09 | 2029-11-13 | 1 | 0d |  | start no earlier than 2019-12-20 |  | 8h |  |
| 9 | 5 | **LhARA 5yr R&D plan** |  | 1200d | 2020-04-01 | 2024-11-05 |  | 0d |  | start no earlier than 2020-04-01 |  | 175664h | 450,000 |
| 10 | 5.1 | **Facility design** |  | 1170d | 2020-04-01 | 2024-09-24 |  | 810d |  |  | Eng_1; Eng_2; FD_PDRA_1 | 28096h |  |
| 11 | 5.1.1 | Development of conceptual design |  | 960d | 2020-04-01 | 2023-12-05 |  | 1550d |  |  |  | 8h |  |
| 12 | 5.1.2 | Development of technical design |  | 1100d | 2020-06-01 | 2024-08-16 | 50 | 1367d |  |  |  | 8h |  |
| 13 | 5.1.3 | CDR (detalled for Stage 1) | milestone | 0d | 2021-09-01 | 2021-09-01 |  | 2139.5d | 32.5d | finish no earlier than 2021-09-01 |  |  |  |
| 14 | 5.1.4 | TDR Stage 1 | milestone | 0d | 2023-05-09 | 2023-05-09 | 25 | 0d |  | finish no earlier than 2022-11-01 |  |  |  |
| 15 | 5.1.5 | TDR Stage 2 | milestone | 0d | 2024-09-24 | 2024-09-24 | 14FS+360d | 140d | 0d |  |  |  |  |
| 16 | 5.3 | **Stage 1 R&D** |  | 1200d | 2020-04-01 | 2024-11-05 |  | 0d |  | start no earlier than 2019-12-19 |  | 44168h | 250,000 |
| 17 | 5.2.1 | **Gabor lens prototypes** |  | 720d | 2020-04-01 | 2023-01-03 |  | 0d |  |  | GL material; GL_PDRA_1; GL_PDRA_2; GL_PG_1; GL_PG_2 | 23040h | 250,000 |
| 18 | 5.2.1.1 | 1st Gen |  | 720d | 2020-04-01 | 2023-01-03 |  | 0d |  |  |  |  |  |
| 19 | 5.2.1.2 | 2nd Gen |  | 720d | 2020-04-01 | 2023-01-03 |  | 0d |  |  |  |  |  |
| 20 | 5.2.1.3 | Electron density measurements |  | 240d | 2021-05-26 | 2022-04-26 | 18SS+300d | 30d | 0d |  |  |  |  |
| 21 | 5.2.1.4 | Alpha source and detector tests |  | 150d | 2022-04-27 | 2022-11-22 | 20 | 30d |  |  |  |  |  |
| 22 | 5.2 | Laser-driven source |  | 1200d | 2020-04-01 | 2024-11-05 |  | 1310d |  |  | LAS_PDRA_1; LAS_PG_1 | 19200h |  |
| 23 | 5.2.3 | Laser-capture interface |  | 720d | 2020-04-01 | 2023-01-03 |  | 1790d |  |  |  |  |  |
| 24 | 5.2.4 | Investigation of space charge algorithms |  | 240d | 2020-04-01 | 2021-03-02 |  | 2270d |  |  | S1_PG_1 | 1920h |  |
| 25 | 5.2.5 | Stage 1 beam line performance evaluation |  | 90d | 2023-01-04 | 2023-05-09 | 27 | 0d |  |  |  |  |  |
| 26 | 5.4.2 | Vertical bend |  | 120d | 2022-10-12 | 2023-03-28 | 27SS-60d | 1730d |  |  |  | 8h |  |
| 27 | 5.2.7 | Capture technology | milestone | 0d | 2023-01-03 | 2023-01-03 | 17 | 0d |  | finish no earlier than 2021-11-01 |  |  |  |

Notes:
- 10: FD_PG_1 to start after 1 year and will work with S1_PG_1 on facility design and vertical bend.
- 19: Investigate injection of electron to fill the lens. / Alternative electron confinement configurations.
- 22: This task includes simulation of the proton and carbon ion beams produced by the laser target interaction, R&D on tape drives for proton and ion production (utilising existing techniques), study of alternative existing technologies for producing ion beams (e.g. gaseoues targets). Operation of the laser and delivering stable beam operation.
- 24: Investigate effect of different space charge algorithms. Optimisation of the beam line including space charge effects.
- 27: Decide if Gabor lenses will be used for the capture or an alternative technology (e.g. solenoids) will be used.

| ID | WBS | Task | Type | Duration | Start | Finish | Predecessors | Total slack | Free slack | Constraint | Resources | Work | Cost |
| --- | --- | --- | --- | --- | --- | --- | --- | --- | --- | --- | --- | --- | --- |
| 28 | 5.4 | **Stage 2 R&D** |  | 1200d | 2020-04-01 | 2024-11-05 |  | 1310d | 0d |  | FFA_PG_1 | 60816h |  |
| 29 | 5.4.1 | **FFA** |  | 1200d | 2020-04-01 | 2024-11-05 |  | 1310d |  |  |  | 35856h |  |
| 30 | 5.4.1.1 | Design and simulation |  | 1200d | 2020-04-01 | 2024-11-05 |  | 1310d | 0d |  |  | 8h |  |
| 31 | 5.4.1.2 | Detailed magnet design |  | 960d | 2021-03-03 | 2024-11-05 | 30SS+240d | 1310d | 0d |  | MAG_ENG_1 [50%]; MAG_PDRA_1; MAG_PG_1 | 19200h |  |
| 32 | 5.4.1.3 | Magnet prototype |  | 480d | 2022-02-02 | 2023-12-05 | 31SS+240d | 1310d | 0d |  |  | 8h |  |
| 33 | 5.4.1.4 | RF cavity design and performance evaluation |  | 720d | 2021-03-03 | 2023-12-05 | 30SS+240d | 1550d |  |  | RF_PDRA_1; RF_PG_1; RF_ENG_1 [50%] | 14400h |  |
| 34 | 5.3.1.5 | Injection and extraction design |  | 280d | 2022-11-09 | 2023-12-05 | 32SS+200d | 1310d | 0d |  | S2_PDRA_1 | 2240h |  |
| 35 | 5.3.2 | Stage 2 performance evaluation |  | 240d | 2023-12-06 | 2024-11-05 | 34 | 1310d |  |  | S2_PDRA_1 | 1920h |  |
| 36 | 5.3.3 | Longitudinal phase space manipulation design, simulation and prototyping |  | 560d | 2022-09-14 | 2024-11-05 | 30FF | 1310d |  |  | S2_PDRA_2; S2_PG_1 | 8960h |  |
| 37 | 5.3.4 | Final beam preparation for in vivo end station |  | 560d | 2022-09-14 | 2024-11-05 | 30FF | 1310d |  |  | S2_PG_2 | 4480h |  |
| 38 | 5.5 | **End stations** |  | 1200d | 2020-04-01 | 2024-11-05 |  | 1310d |  | start no earlier than 2019-12-19 | Rbio_PDRA_1 [50%]; Rbio_PG_1 [50%] | 9600h |  |
| 39 | 5.5.1 | Automation, sample handling, imaging |  | 1200d | 2020-04-01 | 2024-11-05 |  | 1310d |  | start no earlier than 2019-12-19 |  |  |  |
| 40 | 5.6 | **Instrumentation** |  | 1200d | 2020-04-01 | 2024-11-05 |  | 1310d |  | start no earlier than 2019-12-19 | INST_PDRA_1 | 15704h |  |
| 41 | 5.6.1 | Online dosimetry and dose profile |  | 400.8d | 2020-04-01 | 2021-10-13 |  | 1407.6d | 0d | start no earlier than 2019-12-19 |  | 8h |  |
| 42 | 5.5.2 | Absolute dosimetry at ultra-high dose rates |  | 400d | 2020-04-01 | 2021-10-12 |  | 2110d |  |  | INST_PG_1 | 3200h |  |
| 43 | 5.6.2 | Low-energy beam diagnostics |  | 300.8d | 2021-10-13 | 2022-12-08 | 41 | 1407.6d | 0d | start no earlier than 2019-12-19 |  | 8h |  |
| 44 | 5.6.3 | Fast feedback and control |  | 400.8d | 2022-12-08 | 2024-06-21 | 43 | 1407.6d |  | start no earlier than 2019-12-19 |  | 8h |  |
| 45 | 5.5.5 | High-energy beam diagnostics |  | 360d | 2023-06-21 | 2024-11-05 | 28FF | 1310d |  |  | INST_PG_2 | 2880h |  |
| 46 | 5.6 | **Software and Computing** |  | 720d | 2022-02-02 | 2024-11-05 |  | 1310d |  |  | COMP material | 17280h | 200,000 |
| 47 | 5.6.1 | Development of online data processing farm |  | 720d | 2022-02-02 | 2024-11-05 | 28FF | 1310d |  |  | DAQ_PG_1; COMP_TECH_1 [50%] | 8640h |  |
| 48 | 5.6.2 | Development of the controls and monitoring computing platform |  | 720d | 2022-02-02 | 2024-11-05 | 28FF | 1310d |  |  | CNM_PDRA_1; COMP_TECH_1 [50%] | 8640h |  |
| 49 | 6 | **Gateway process** |  | 787d | 2020-06-01 | 2023-06-06 |  | 0d |  |  |  |  |  |
| 50 | 6.1 | GW0 -- Strategic assessment | milestone | 0d | 2020-06-01 | 2020-06-01 |  | 0d |  | must start on 2020-06-01 |  |  |  |
| 51 | 6.2 | GW1 -- Business justification | milestone | 0d | 2021-02-05 | 2021-02-05 | 50FS+9mo | 2107d | 0d |  |  |  |  |
| 52 | 6.3 | GW2 -- Delivery strategy | milestone | 0d | 2021-10-15 | 2021-10-15 | 51FS+9mo, 13 | 2107d |  |  |  |  |  |
| 53 | 6.4 | GW3 -- Investment decision | milestone | 0d | 2023-06-06 | 2023-06-06 | 14FS+1mo | 0d |  |  |  |  |  |

Notes:
- 37: Includes spot scanning, potentially micro-beam studies and experimental tests at other facilities.
- 39: Includes automation within a hypoxic environment
- 43: Diagnostics device to measure the intensity profile of the low-energy proton beam.
- 45: Includes "conventional" beam diagnostics in the extraction/transfer to in vivo line, diagnostics for the FFA and bunch length measurements.
- 46: Computing material £200k is for DAQ hardware and firmware, controls and monitoring hardware, common computing (specialised server for running space charge simulations, and for purchasing time on HPC farms) and licenses for commercial software (CAD, FEA, etc).
